# Spectrometer Solenoids Ver10

Schedule from MS Project, 2010-10-27 to 2012-07-03, status date 2011-05-05, A marks actual dates.

## Calendars

- Standard: Mon-Fri 08:00-12:00, 13:00-17:00; Sat-Sun off. Exceptions (off unless hours are given): 2010-12-25 to 2011-01-03 (Christmas Holidays).

## Resources

| Resource |
| --- |
| Sisi Shan |
| Roy Preece |
| WANG - Design |
| Steve Virostek |
| Tapio |
| Soren Prestemon |
| WANG - Mech Tech |
| WANG - Welder |
| Bert WANG |
| LBNL - Mech Tech |
| Dennis Calais |
| LBNL - Elec Tech |
| LBNL - Cryo Tech |
| LBNL - Survey |
| Pierre-Ange |
| Felix |
| FermiLab - Physicist |

## Schedule

| ID | WBS | Task | Type | Duration | Start | Finish | Predecessors | Complete | Remaining | Total slack | Free slack | Constraint | Resources | Work | Actual work |
| --- | --- | --- | --- | --- | --- | --- | --- | --- | --- | --- | --- | --- | --- | --- | --- |
| 1 | 1 | **Preparation, Review and Analysis** |  | 164d | 2010-10-27 A | 2011-06-21 |  | 81% | 31.74d | 262.5d |  |  |  | 1120h | 1048h |
| 2 | 1.1 | Spectrometer Solenoid MICE Review | milestone | 0d | 2010-10-27 A | 2010-10-27 A |  | 100% |  |  |  | start no earlier than 2010-10-27 |  |  |  |
| 3 | 1.2 | Preliminary Comments issued from MICE Committee | milestone | 0d | 2010-11-22 A | 2010-11-22 A |  | 100% |  |  |  | start no earlier than 2010-11-22 |  |  |  |
| 4 | 1.3 | MICE Committee final report distributed | milestone | 0d | 2010-12-14 A | 2010-12-14 A |  | 100% |  |  |  | start no earlier than 2010-12-14 |  |  |  |
| 5 | 1.4 | MAP PMG Meeting | milestone | 0d | 2011-01-12 A | 2011-01-12 A |  | 100% |  |  |  | start no earlier than 2011-01-12 |  |  |  |
| 6 | 1.5 | Preliminary comments preparation |  | 2w | 2010-11-22 A | 2010-12-03 A | 3 | 100% |  |  |  |  | Steve Virostek | 80h | 80h |
| 7 | 1.6 | Preparation of responses to MICE committee and magnet repair plan |  | 3w | 2010-10-27 A | 2010-11-16 A | 2 | 100% |  |  |  |  | Steve Virostek; Soren Prestemon; Tapio | 360h | 360h |
| 8 | 1.7 | Delivery of the Vector Fields QUENCH code | milestone | 0d | 2010-12-13 A | 2010-12-13 A |  | 100% |  |  |  | start no earlier than 2010-12-13 |  |  |  |
| 9 | 1.8 | Heat leak and Cryogenic calculations |  | 2mo | 2010-12-14 A | 2011-02-15 A | 4 | 100% |  |  |  |  | Tapio | 320h | 320h |
| 10 | 1.9 | Model construction and analyusis of quench protection response preparation |  | 9w | 2010-12-14 A | 2011-02-22 | 4 | 80% | 1.8w | 155d | 40d |  | Soren Prestemon | 360h | 288h |
| 11 | 1.10 | Review and check of Quench protection work (Technical board to assign reveiwer) |  | 6w | 2011-04-20 A | 2011-05-31 | 10 | 80% | 1.2w | 91d | 0d | finish no earlier than 2011-05-31 |  |  |  |
| 12 | 1.11 | Decision point for Quench protection | milestone | 0d | 2011-05-31 | 2011-05-31 | 11 |  |  | 250.5d |  |  |  |  |  |
| 13 | 1.12 | Manufacture drilling fixture and drill holes for 5+5 (rdudancy) |  | 3w | 2011-06-01 | 2011-06-21 | 11 |  |  | 91d | 0d |  |  |  |  |
| 14 | 2 | **Colaboration Meetings** |  | 105d | 2011-02-14 A | 2011-07-08 |  | 63% | 39.38d | 249.5d |  |  |  |  |  |
| 15 | 2.1 | RAL Meeting |  | 5d | 2011-02-14 A | 2011-02-18 A |  | 100% |  |  |  | start no earlier than 2011-02-14 |  |  |  |
| 16 | 2.2 | Oxford Meeting |  | 3d | 2011-07-06 | 2011-07-08 |  |  |  | 249.5d |  | start no earlier than 2011-07-06 |  |  |  |
| 17 | 3 | **Design - Magnet Modification** |  | 21d | 2011-05-02 A | 2011-05-30 |  | 86% | 2.85d | 99d |  |  |  | 688h | 560h |
| 18 | 3.1 | Design new tower assembly for 5 +1 cooler arangement |  | 4w | 2011-05-02 A | 2011-05-27 A | 9 | 100% |  |  |  | start no earlier than 2011-05-02 | WANG - Design | 160h | 160h |
| 19 | 3.2 | Design for 5 cryo coolers in the Cold Mass / Body cut for Ressistor block access |  | 4w | 2011-05-02 A | 2011-05-27 A | 18SS | 100% |  |  |  |  | WANG - Design | 160h | 160h |
| 20 | 3.3 | Design for new Radiation shield |  | 4w | 2011-05-02 A | 2011-05-27 A | 18SS | 100% |  |  |  |  | WANG - Design | 160h | 160h |
| 21 | 3.4 | Design for new intelt / vent tubes including radiation baffle |  | 4w | 2011-05-02 A | 2011-05-27 | 18SS | 50% | 2w | 99d | 0d |  | WANG - Design | 160h | 80h |
| 22 | 3.5 | Design work completed | milestone | 0d | 2011-05-27 | 2011-05-27 | 21 |  |  | 99d | 0d |  |  |  |  |
| 23 | 3.6 | Internal design review to asses the designs for towers, cold mass, radiation shield and inlet |  | 1d | 2011-05-30 | 2011-05-30 | 22 |  |  | 99d | 0d |  | Steve Virostek; Roy Preece; Tapio; Soren Prestemon; WANG - Design; Bert WANG | 48h |  |
| 24 | 3.7 | Designs for Towers, cold mass, radiation shield and inlet accepted | milestone | 0d | 2011-05-30 | 2011-05-30 | 23 |  |  | 98d | 0d |  |  |  |  |

| ID | WBS | Task | Type | Duration | Start | Finish | Predecessors | Total slack | Free slack | Constraint | Resources | Work |
| --- | --- | --- | --- | --- | --- | --- | --- | --- | --- | --- | --- | --- |
| 25 | 4 | **Fabrication and Assembly Solenoid 2** |  | 109.5d | 2011-05-27 | 2011-10-28 |  | 0d |  |  |  | 1540h |
| 26 | 4.1 | **Fabrication** |  | 109.5d | 2011-05-27 | 2011-10-28 |  | 0d |  |  |  | 1196h |
| 27 | 4.1.1 | **Cold Mass for Solenoid 2** |  | 20d | 2011-05-31 | 2011-06-27 |  | 99d |  |  |  | 200h |
| 28 | 4.1.1.1 | Machine 5 holes for the cryo coolers |  | 2d | 2011-05-31 | 2011-06-01 | 24 | 99d | 0d | start no earlier than 2011-01-10 | WANG - Mech Tech | 16h |
| 29 | 4.1.1.2 | Cut section from coldmass cover for ressistor access |  | 1d | 2011-06-02 | 2011-06-02 | 28 | 267d | 0d |  | WANG - Mech Tech | 8h |
| 30 | 4.1.1.3 | Remove ressistor and diode pack from the cold mass |  | 2d | 2011-06-03 | 2011-06-06 | 29 | 267d | 0d |  | WANG - Mech Tech | 16h |
| 31 | 4.1.1.4 | Diss-assemble the ressistor / diode pack and re-build with new ressistor conduction plate |  | 2d | 2011-06-07 | 2011-06-08 | 30 | 267d | 0d |  | WANG - Mech Tech | 16h |
| 32 | 4.1.1.5 | Install newly assebled ressitor / diode pack into the cold mass |  | 2d | 2011-06-09 | 2011-06-10 | 31 | 267d |  |  | WANG - Mech Tech | 16h |
| 33 | 4.1.1.6 | Insert Bimetal inserts into holes |  | 1d | 2011-06-02 | 2011-06-02 | 28 | 99d | 0d |  | WANG - Mech Tech | 8h |
| 34 | 4.1.1.7 | Weld cooler tubes and bellow |  | 1d | 2011-06-03 | 2011-06-03 | 33 | 99d | 0d |  | WANG - Welder | 8h |
| 35 | 4.1.1.8 | Weld new material over the ressistor / diode area |  | 1d | 2011-06-06 | 2011-06-06 | 34 | 99d | 0d |  | WANG - Welder | 8h |
| 36 | 4.1.1.9 | Ressistor / Diode pack with conduction plate installed | milestone | 0d | 2011-06-06 | 2011-06-06 | 35 | 99d | 0d |  |  |  |
| 37 | 4.1.1.10 | Construct new large bore Fill tube with stinger tube and radiation baffle |  | 1d | 2011-06-07 | 2011-06-07 | 36 | 99d | 0d |  | LBNL - Mech Tech | 8h |
| 38 | 4.1.1.11 | Construct new large bore Vent tube with He level sensor and raditation baffle |  | 1d | 2011-06-07 | 2011-06-07 | 37SS | 99d | 0d |  | LBNL - Mech Tech | 8h |
| 39 | 4.1.1.12 | Cut old fill / vent tubes to accept new larger bore tubes |  | 1d | 2011-06-08 | 2011-06-08 | 38 | 99d | 0d |  | WANG - Mech Tech | 8h |
| 40 | 4.1.1.13 | Install and weld new larger bore Fill / Vent tubes - Feed Instrumentation lines through level tube |  | 1d | 2011-06-09 | 2011-06-09 | 39 | 99d | 8d |  | WANG - Mech Tech; WANG - Welder; Roy Preece; Dennis Calais | 32h |
| 41 | 4.1.1.14 | Cold Mass ready for He leak checking | milestone | 0d | 2011-06-21 | 2011-06-21 | 40, 13 | 91d | 0d |  |  |  |
| 42 | 4.1.1.15 | Install heat intercept to main fill line |  | 1d | 2011-06-22 | 2011-06-22 | 41 | 91d | 0d |  | WANG - Mech Tech | 8h |
| 43 | 4.1.1.16 | Install 4K lead heat intercepts |  | 1d | 2011-06-23 | 2011-06-23 | 42 | 91d | 0d |  | WANG - Mech Tech | 8h |
| 44 | 4.1.1.17 | Attach vacuum rig and evacuate |  | 2d | 2011-06-22 | 2011-06-23 | 41 | 248d | 0d |  | LBNL - Mech Tech | 16h |
| 45 | 4.1.1.18 | Vacuum leak check |  | 2d | 2011-06-24 | 2011-06-27 | 44 | 248d | 0d |  | LBNL - Mech Tech | 16h |
| 46 | 4.1.1.19 | Cold mass ready for MLI wrapping | milestone | 0d | 2011-06-27 | 2011-06-27 | 45 | 246d |  |  |  |  |
| 47 | 4.1.2 | **Radiation Shield for Solenoid 2 and 1** |  | 33d | 2011-05-27 | 2011-07-13 |  | 0d |  |  |  | 128h |
| 48 | 4.1.2.1 | Ship out material from WANG to rolling mill | milestone | 0d | 2011-05-27 | 2011-05-27 | 20 | 0d |  |  |  |  |
| 49 | 4.1.2.2 | Radiation shield work at the rolling mill |  | 4w | 2011-05-30 | 2011-06-24 | 48 | 0d |  |  |  |  |
| 50 | 4.1.2.3 | Radiation Shield 2 and 1 arrive at WANG from rolling mill | milestone | 0d | 2011-06-24 | 2011-06-24 | 49 | 0d |  |  |  |  |
| 51 | 4.1.2.4 | Machine hole in the radiation shield for cryo coolers and cold mass supports |  | 1w | 2011-06-27 | 2011-07-01 | 50 | 0d |  |  | WANG - Mech Tech | 40h |
| 52 | 4.1.2.5 | Machine end plates for the radiation shields |  | 1w | 2011-07-04 | 2011-07-08 | 51 | 0d |  |  | WANG - Mech Tech | 40h |
| 53 | 4.1.2.6 | Attached thermal intercepts for the copper tower and straps to cold mass supports and tubes |  | 3d | 2011-07-11 | 2011-07-13 | 52 | 0d |  |  | WANG - Mech Tech; WANG - Welder | 48h |
| 54 | 4.1.2.7 | Radiation Shield parts ready for MLI wrapping | milestone | 0d | 2011-07-13 | 2011-07-13 | 53 | 0d |  |  |  |  |

| ID | WBS | Task | Type | Duration | Start | Finish | Predecessors | Total slack | Free slack | Resources | Work |
| --- | --- | --- | --- | --- | --- | --- | --- | --- | --- | --- | --- |
| 55 | 4.1.3 | **Cooler Tower** |  | 56.5d | 2011-06-22 | 2011-09-08 |  | 93d |  |  | 176h |
| 56 | 4.1.3.1 | Machine new hole in the Vacuum vessel for the fifth cryo cooler |  | 1d | 2011-06-22 | 2011-06-22 | 24, 41 | 257d | 0d | WANG - Mech Tech | 8h |
| 57 | 4.1.3.2 | Machine new hole for the Vacuum pumpout port |  | 1d | 2011-06-23 | 2011-06-23 | 56 | 257d | 0d | WANG - Mech Tech | 8h |
| 58 | 4.1.3.3 | Machine new port for the HTS leads an vacuum equipment port |  | 1d | 2011-06-24 | 2011-06-24 | 57 | 257d | 0d | WANG - Mech Tech | 8h |
| 59 | 4.1.3.4 | Machining work on Vacuum Vessel Completed | milestone | 0d | 2011-06-24 | 2011-06-24 | 58 | 232.5d |  |  |  |
| 60 | 4.1.3.5 | Manufacture new tower plates |  | 1w | 2011-06-24 | 2011-06-30 | 24, 43 | 91d | 0d | WANG - Mech Tech | 40h |
| 61 | 4.1.3.6 | Weld top and end plates to Vacuum vessel on both towers |  | 3d | 2011-07-01 | 2011-07-05 | 60 | 91d | 27d | WANG - Welder | 24h |
| 62 | 4.1.3.7 | Install cooler sleeves and copper plates |  | 2d | 2011-08-12 | 2011-08-15 | 61, 126 | 64d | 0d | WANG - Mech Tech | 16h |
| 63 | 4.1.3.8 | Weld cooler sleeves to cold mass / Cooler towers |  | 2d | 2011-08-16 | 2011-08-17 | 62 | 64d | 0d | WANG - Mech Tech | 16h |
| 64 | 4.1.3.9 | Install Copper straps between 1st stage and Copper plates |  | 1d | 2011-08-19 | 2011-08-19 | 114 | 64d | 0d | WANG - Mech Tech | 8h |
| 65 | 4.1.3.10 | Cooler sleeves and radiation shield to 1st stage completed | milestone | 0d | 2011-08-19 | 2011-08-19 | 64 | 64d | 0d |  |  |
| 66 | 4.1.3.11 | Install the warm leads and HV feedthroughs |  | 1d | 2011-08-22 | 2011-08-22 | 65 | 64d | 0d | WANG - Mech Tech | 8h |
| 67 | 4.1.3.12 | Install the heat intercepts to Copper plates |  | 2d | 2011-08-23 | 2011-08-24 | 66 | 64d | 0d | WANG - Mech Tech | 16h |
| 68 | 4.1.3.13 | Install thermal connection from 1st stage Copper plates to Shield |  | 1d | 2011-08-26 | 2011-08-29 | 102 | 64d | 0d | WANG - Mech Tech | 8h |
| 69 | 4.1.3.14 | Weld plates front and back |  | 2d | 2011-09-06 | 2011-09-08 | 87 | 64d | 0d | WANG - Welder | 16h |
| 70 | 4.1.4 | **Fill and Vent Tower** |  | 9d | 2011-10-12 | 2011-10-25 |  | 173d |  |  | 72h |
| 71 | 4.1.4.1 | Install and weld lower sections of fill / vent tower to Vacuum vessel |  | 2d | 2011-10-12 | 2011-10-14 | 137 | 170.5d | 0d | WANG - Mech Tech | 16h |
| 72 | 4.1.4.2 | Install instrumentation feedthrough |  | 1d | 2011-10-14 | 2011-10-17 | 71 | 170.5d | 0d | WANG - Mech Tech | 8h |
| 73 | 4.1.4.3 | Check all instrumentation lines for activity |  | 1d | 2011-10-17 | 2011-10-18 | 72 | 170.5d | 0d | LBNL - Elec Tech | 8h |
| 74 | 4.1.4.4 | Instrumentation lines installed and tested | milestone | 0d | 2011-10-18 | 2011-10-18 | 73 | 173d | 0d |  |  |
| 75 | 4.1.4.5 | Weld the upper portion of the tower |  | 2d | 2011-10-18 | 2011-10-20 | 24, 74 | 170.5d | 0d | WANG - Welder | 16h |
| 76 | 4.1.4.6 | Complete assembly of fill and vent tower and install |  | 3d | 2011-10-20 | 2011-10-25 | 75 | 170.5d | 0d | WANG - Mech Tech | 24h |
| 77 | 4.1.4.7 | Fill / Vent Tower completeed | milestone | 0d | 2011-10-25 | 2011-10-25 | 76 | 160.5d |  |  |  |
| 78 | 4.1.5 | **MLI** |  | 73.5d | 2011-06-28 | 2011-10-07 |  | 13d |  |  | 336h |
| 79 | 4.1.5.1 | Wrap cold mass 2 with MLI |  | 8d | 2011-06-28 | 2011-07-07 | 45 | 248d | 0d | LBNL - Cryo Tech | 64h |
| 80 | 4.1.5.2 | Sign off quality of MLI layers on cold mass 2 | milestone | 0d | 2011-07-07 | 2011-07-07 | 79 | 223.5d | 0d |  |  |
| 81 | 4.1.5.3 | Wrap radiation shield 2 with MLI |  | 6d | 2011-07-15 | 2011-07-22 | 100, 54 | 0d |  | LBNL - Cryo Tech | 48h |
| 82 | 4.1.5.4 | Sign off quality of MIL layers on radiation shield 2 | milestone | 0d | 2011-07-22 | 2011-07-22 | 81 | 0d |  |  |  |
| 83 | 4.1.5.5 | Wrap cold mass supports with MLI |  | 4d | 2011-07-27 | 2011-08-01 | 121 | 0d |  | LBNL - Cryo Tech | 32h |
| 84 | 4.1.5.6 | Sign off quality of MLI wrap around supports | milestone | 0d | 2011-08-01 | 2011-08-01 | 83 | 221d |  |  |  |
| 85 | 4.1.5.7 | Wrap upper and lower tower area with MLI |  | 4d | 2011-08-29 | 2011-09-02 | 68 | 64d | 0d | LBNL - Cryo Tech | 32h |
| 86 | 4.1.5.8 | Wrap 1st stage Copper plates to shield connections |  | 2d | 2011-09-02 | 2011-09-06 | 85 | 64d | 0d | LBNL - Cryo Tech | 16h |
| 87 | 4.1.5.9 | Sign off Tower MLI wrapping | milestone | 0d | 2011-09-06 | 2011-09-06 | 86 | 63d | 0d |  |  |
| 88 | 4.1.5.10 | Apply MLI to Shield and cold mass bore |  | 6d | 2011-09-08 | 2011-09-16 | 69, 54 | 64d | 0d | LBNL - Cryo Tech | 48h |
| 89 | 4.1.5.11 | Sign off Shield and cold mass bore wrapping | milestone | 0d | 2011-09-16 | 2011-09-16 | 88 | 63d | 0d |  |  |
| 90 | 4.1.5.12 | Integrate cold mass MLI with bore MLI |  | 2d | 2011-09-21 | 2011-09-23 | 134 | 192.5d | 0d | LBNL - Cryo Tech | 16h |
| 91 | 4.1.5.13 | Sign off cold mass to bore MLI conection | milestone | 0d | 2011-09-23 | 2011-09-23 | 90 | 182.5d |  |  |  |
| 92 | 4.1.5.14 | Apply MLI to shield ends |  | 4d | 2011-09-22 | 2011-09-28 | 135 | 64d | 0d | LBNL - Cryo Tech | 32h |
| 93 | 4.1.5.15 | Apply MLI between warm bore and shield bore |  | 4d | 2011-09-28 | 2011-10-04 | 92 | 70d | 0d | LBNL - Cryo Tech | 32h |
| 94 | 4.1.5.16 | Sign off shield MLI and warm bore MLI | milestone | 0d | 2011-10-04 | 2011-10-04 | 92, 93 | 63d | 0d |  |  |
| 95 | 4.1.5.17 | Integrate MLI between warm bore and shield ends |  | 2d | 2011-10-05 | 2011-10-07 | 136 | 70d | 0d | LBNL - Cryo Tech | 16h |
| 96 | 4.1.5.18 | Sign off MLI at warm bore / shield connection | milestone | 0d | 2011-10-07 | 2011-10-07 | 95 | 63d | 0d |  |  |

| ID | WBS | Task | Type | Duration | Start | Finish | Predecessors | Total slack | Free slack | Constraint | Resources | Work |
| --- | --- | --- | --- | --- | --- | --- | --- | --- | --- | --- | --- | --- |
| 97 | 4.1.6 | **Instrumentation** |  | 79d | 2011-06-28 | 2011-10-14 |  | 12d |  |  |  | 36h |
| 98 | 4.1.6.1 | Install level sensor cold mass 2 - new fill line / vent line |  | 4h | 2011-10-14 | 2011-10-14 | 71 | 177d |  |  | LBNL - Elec Tech | 4h |
| 99 | 4.1.6.2 | Install external temp sensors cold mass 2 |  | 4h | 2011-06-28 | 2011-06-28 | 45 | 255.5d |  |  | LBNL - Elec Tech | 4h |
| 100 | 4.1.6.3 | Install temp sensors radiation shield 2 |  | 1d | 2011-07-14 | 2011-07-14 | 54 | 0d |  |  | LBNL - Elec Tech | 8h |
| 101 | 4.1.6.4 | Add temp sensors to cold mass supports |  | 1d | 2011-08-04 | 2011-08-04 | 123 | 228d |  |  | LBNL - Elec Tech | 8h |
| 102 | 4.1.6.5 | Attach thermal sensors to the Copper plates |  | 4h | 2011-08-26 | 2011-08-26 | 105 | 64d | 0d |  | LBNL - Elec Tech | 4h |
| 103 | 4.1.6.6 | Apply thermal instramentation top shield |  | 1d | 2011-09-22 | 2011-09-23 | 135 | 192.5d |  |  | LBNL - Elec Tech | 8h |
| 104 | 4.1.7 | **Current Leads** |  | 1d | 2011-08-25 | 2011-08-25 |  | 64d |  |  |  | 8h |
| 105 | 4.1.7.1 | Install HTS leads with upper and lower voltage taps |  | 1d | 2011-08-25 | 2011-08-25 | 67 | 64d | 0d |  | WANG - Mech Tech | 8h |
| 106 | 4.1.8 | **Coolers** |  | 109.5d | 2011-05-30 | 2011-10-28 |  | 122d |  |  |  | 240h |
| 107 | 4.1.8.1 | Purchase Water cooler tower | milestone | 0d | 2011-05-30 | 2011-05-30 |  | 192.5d | 0d | start no earlier than 2011-05-30 |  |  |
| 108 | 4.1.8.2 | Delivery of Water Cooler Tower |  | 12w | 2011-05-30 | 2011-08-19 | 107 | 192.5d | 0d |  |  |  |
| 109 | 4.1.8.3 | Install manifold for cryo cooler compressor cooling water |  | 4w | 2011-07-25 | 2011-08-19 | 108FS-20d | 219.5d | 0d |  | WANG - Mech Tech | 160h |
| 110 | 4.1.8.4 | Cooling water ready for Cryo Coolers | milestone | 0d | 2011-08-19 | 2011-08-19 | 109 | 192.5d |  |  |  |  |
| 111 | 4.1.8.5 | Remove Copper parts from old cooler tubes and clean up for re-use |  | 1w | 2011-05-31 | 2011-06-06 | 23 | 252d | 0d |  |  |  |
| 112 | 4.1.8.6 | Manufacture new cooler tuibe cans 10 parts |  | 1w | 2011-06-07 | 2011-06-13 | 111 | 252d | 0d |  | WANG - Mech Tech | 40h |
| 113 | 4.1.8.7 | Braze Stainless Steel cans to copper cooler parts |  | 1w | 2011-06-14 | 2011-06-20 | 112 | 252d | 38d |  |  |  |
| 114 | 4.1.8.8 | Install Single stage cooler to Tower |  | 1d | 2011-08-18 | 2011-08-18 | 63 | 64d | 0d |  | WANG - Mech Tech | 8h |
| 115 | 4.1.8.9 | Install the 2 stage coolers to sleeves |  | 2d | 2011-10-25 | 2011-10-27 | 142, 113 | 167.5d | 0d |  | WANG - Mech Tech | 16h |
| 116 | 4.1.8.10 | Install cro cooler hoses |  | 1d | 2011-10-27 | 2011-10-28 | 115 | 167.5d | 0d |  | Dennis Calais | 8h |
| 117 | 4.1.8.11 | Recharge for UK operation |  | 1d | 2011-10-27 | 2011-10-28 | 116SS | 167.5d |  |  | Dennis Calais | 8h |
| 118 | 4.1.8.12 | Coolers ready for use | milestone | 0d | 2011-10-28 | 2011-10-28 | 116, 145 | 167.5d |  |  |  |  |
| 119 | 4.2 | **Assembly** |  | 68.5d | 2011-07-25 | 2011-10-27 |  | 0d |  |  |  | 344h |
| 120 | 4.2.1 | Assembly Start on Solenoid 2 | milestone | 0d | 2011-07-25 | 2011-07-25 | 121SS | 227d |  |  |  |  |
| 121 | 4.2.2 | Suspend shield around the cold mass |  | 2d | 2011-07-25 | 2011-07-26 | 82, 54 | 0d |  |  | WANG - Mech Tech | 16h |
| 122 | 4.2.3 | Radiation shield around cold mass | milestone | 0d | 2011-07-26 | 2011-07-26 | 121 | 225d |  |  |  |  |
| 123 | 4.2.4 | Install cold mass supports to Vacuum vessel |  | 2d | 2011-08-02 | 2011-08-03 | 83 | 0d |  |  | WANG - Mech Tech | 16h |
| 124 | 4.2.5 | Move vacuum vessel over the shield / cold mass assembly |  | 2d | 2011-08-04 | 2011-08-05 | 123 | 0d |  |  | WANG - Mech Tech | 16h |
| 125 | 4.2.6 | Connect the supports to the cold mass |  | 2d | 2011-08-08 | 2011-08-09 | 124 | 0d |  |  | WANG - Mech Tech | 16h |
| 126 | 4.2.7 | Suspend the cold mass / shield inside the vacuum vessel |  | 2d | 2011-08-10 | 2011-08-11 | 125 | 0d |  |  | WANG - Mech Tech | 16h |
| 127 | 4.2.8 | Weld the Cooler sleeves to the cold mass stub tubes |  | 2d | 2011-08-12 | 2011-08-15 | 126, 113 | 214d | 0d |  | WANG - Welder | 16h |
| 128 | 4.2.9 | Align the cold mass to the vacuum vessel |  | 1w | 2011-08-16 | 2011-08-22 | 127 | 214d | 0d |  | LBNL - Survey | 40h |
| 129 | 4.2.10 | Cold mass alighned to the Vacuum Vessel | milestone | 0d | 2011-08-22 | 2011-08-22 | 128 | 216.5d | 0d |  |  |  |
| 130 | 4.2.11 | Cold mass and shield inside the vacuum vessel | milestone | 0d | 2011-08-22 | 2011-08-22 | 129 | 216.5d | 0d |  |  |  |
| 131 | 4.2.12 | Connect cold mass support intercepts to the shield |  | 1d | 2011-08-23 | 2011-08-23 | 130 | 214d | 0d |  | WANG - Mech Tech | 8h |
| 132 | 4.2.13 | Add copper sheet to the holes in the shield |  | 1d | 2011-08-24 | 2011-08-24 | 131 | 214d |  |  | WANG - Mech Tech | 8h |
| 133 | 4.2.14 | Align Vacuum vessel end plate to the cold mass bore |  | 2d | 2011-09-16 | 2011-09-20 | 89 | 64d | 0d |  | WANG - Mech Tech | 16h |
| 134 | 4.2.15 | Install shield bore tube |  | 1d | 2011-09-20 | 2011-09-21 | 133 | 64d | 0d |  | WANG - Mech Tech | 8h |
| 135 | 4.2.16 | Weld shield end plates |  | 1d | 2011-09-21 | 2011-09-22 | 134 | 64d | 0d |  | WANG - Welder | 8h |
| 136 | 4.2.17 | Install warm bore |  | 1d | 2011-10-04 | 2011-10-05 | 94 | 70d | 0d |  | WANG - Mech Tech | 8h |
| 137 | 4.2.18 | Weld end plates to the Vacuum vessel |  | 3d | 2011-10-07 | 2011-10-12 | 96 | 70d | 0d |  | WANG - Welder | 24h |
| 138 | 4.2.19 | Vaccum vessel closed | milestone | 0d | 2011-10-12 | 2011-10-12 | 137 | 70d | 0d |  |  |  |
| 139 | 4.2.20 | Install vacuum system to solenoid |  | 1d | 2011-10-12 | 2011-10-13 | 138 | 70d | 0d |  | LBNL - Mech Tech; FermiLab - Physicist | 16h |
| 140 | 4.2.21 | Commision vacuum systems and initial pump down |  | 3d | 2011-10-13 | 2011-10-18 | 139 | 70d | 0d |  | FermiLab - Physicist; LBNL - Mech Tech | 48h |
| 141 | 4.2.22 | Test LN2 cooldown system |  | 1d | 2011-10-18 | 2011-10-19 | 140 | 174.5d |  |  | FermiLab - Physicist | 8h |
| 142 | 4.2.23 | Detailed leak checking of the Vacuum vessel and cold mass |  | 5d | 2011-10-18 | 2011-10-25 | 140 | 70d | 0d |  | LBNL - Mech Tech | 40h |
| 143 | 4.2.24 | Leak check of Vacuum vessel and cold mass completed | milestone | 0d | 2011-10-25 | 2011-10-25 | 142 | 70d | 0d |  |  |  |
| 144 | 4.2.25 | Connect power leads |  | 1d | 2011-10-25 | 2011-10-26 | 143 | 70d | 0d |  | LBNL - Elec Tech | 8h |
| 145 | 4.2.26 | Connect all instrumentation cables |  | 1d | 2011-10-26 | 2011-10-27 | 144 | 70d | 0d |  | LBNL - Elec Tech | 8h |
| 146 | 4.2.27 | Solenoid ready for cool down and training | milestone | 0d | 2011-10-27 | 2011-10-27 | 145 | 70d | 0d |  |  |  |

| ID | WBS | Task | Type | Duration | Start | Finish | Predecessors | Total slack | Free slack | Constraint | Resources | Work |
| --- | --- | --- | --- | --- | --- | --- | --- | --- | --- | --- | --- | --- |
| 147 | 5 | **Fabrication and Assembly Solenoid 1** |  | 146.5d | 2011-07-13 | 2012-02-02 |  | 27d |  |  |  | 1220h |
| 148 | 5.1 | **Fabrication** |  | 139.5d | 2011-07-13 | 2012-01-24 |  | 27d |  |  |  | 868h |
| 149 | 5.1.1 | **Cold Mass for Solenoid 1** |  | 28.5d | 2011-08-19 | 2011-09-28 |  | 0d |  |  |  | 172h |
| 150 | 5.1.1.1 | Lift Cold Mass 1 and place onto support beam |  | 2d | 2011-08-19 | 2011-08-22 | 126FS+5d | 0d |  |  | WANG - Mech Tech | 16h |
| 151 | 5.1.1.2 | Open cold mass and stabalise leads |  | 2d | 2011-08-23 | 2011-08-24 | 150 | 0d |  | start no earlier than 2010-11-15 | WANG - Mech Tech | 16h |
| 152 | 5.1.1.3 | Remove ressistor / Diode pack from Cold Mass |  | 2d | 2011-08-25 | 2011-08-26 | 151 | 0d |  |  | WANG - Mech Tech | 16h |
| 153 | 5.1.1.4 | Dis-assemble the ressistor / Diode pack and re-build with new ressirto conduction block |  | 2d | 2011-08-29 | 2011-08-30 | 152 | 0d |  |  | WANG - Mech Tech | 16h |
| 154 | 5.1.1.5 | Install newly assembled ressistor / diode pack into the Cold Mass |  | 2d | 2011-08-31 | 2011-09-01 | 153 | 0d |  |  | WANG - Mech Tech | 16h |
| 155 | 5.1.1.6 | Machine hole for the fifth cryocooler |  | 1d | 2011-09-02 | 2011-09-02 | 154 | 0d |  | start no earlier than 2011-01-10 | WANG - Mech Tech | 8h |
| 156 | 5.1.1.7 | Insert Bimetal insert into hole |  | 1d | 2011-09-05 | 2011-09-05 | 155 | 0d |  |  | WANG - Mech Tech | 8h |
| 157 | 5.1.1.8 | Weld cooler tubes and bellow |  | 1d | 2011-09-06 | 2011-09-06 | 156 | 0d |  |  | WANG - Welder | 8h |
| 158 | 5.1.1.9 | Weld new material over ressistor / diode pack area |  | 1d | 2011-09-07 | 2011-09-07 | 157 | 0d |  |  | WANG - Welder | 8h |
| 159 | 5.1.1.10 | Rsssistor / Diode pack with cionduction plate installed | milestone | 0d | 2011-09-07 | 2011-09-07 | 158 | 0d |  |  |  |  |
| 160 | 5.1.1.11 | Install and weld new larger bore Fill / Vent tubes - Feed instrumentation lines through level tube |  | 2d | 2011-09-08 | 2011-09-09 | 159 | 0d |  |  | WANG - Mech Tech | 16h |
| 161 | 5.1.1.12 | Drill holes in the cold mass for heater 5+5 |  | 2w | 2011-09-12 | 2011-09-23 | 160 | 0d |  |  |  |  |
| 162 | 5.1.1.13 | Cold mass ready for vacuum leak checking | milestone | 0d | 2011-09-23 | 2011-09-23 | 161 | 0d |  |  |  |  |
| 163 | 5.1.1.14 | Install heat intercept to main fill line |  | 4h | 2011-09-26 | 2011-09-26 | 162 | 0d |  |  | WANG - Mech Tech | 4h |
| 164 | 5.1.1.15 | Install 4K lead heat intercepts |  | 1d | 2011-09-26 | 2011-09-27 | 163 | 0d |  |  | WANG - Mech Tech | 8h |
| 165 | 5.1.1.16 | Attach vacuum rig and evacuate |  | 2d | 2011-09-12 | 2011-09-13 | 160 | 200d |  |  | LBNL - Mech Tech | 16h |
| 166 | 5.1.1.17 | Vacuum leak check |  | 2d | 2011-09-26 | 2011-09-28 | 163 | 165.5d | 0d |  | LBNL - Mech Tech | 16h |
| 167 | 5.1.1.18 | Cold mass ready for MLI wrapping | milestone | 0d | 2011-09-28 | 2011-09-28 | 166 | 189.5d |  |  |  |  |
| 168 | 5.1.2 | **Cooler Tower** |  | 32d | 2011-09-27 | 2011-11-10 |  | 0d |  |  |  | 184h |
| 169 | 5.1.2.1 | Machine new holes in vessel for 5 cryo coolers |  | 2d | 2011-09-27 | 2011-09-29 | 164 | 0d |  |  | WANG - Mech Tech | 16h |
| 170 | 5.1.2.2 | Manufacture new tower plates |  | 1w | 2011-09-29 | 2011-10-06 | 169 | 0d |  |  | WANG - Mech Tech | 40h |
| 171 | 5.1.2.3 | Machine new hole for vacuum pumpout port |  | 2d | 2011-10-06 | 2011-10-10 | 170 | 0d |  |  | WANG - Mech Tech | 16h |
| 172 | 5.1.2.4 | Weld top and end plates to Vacuum vessel |  | 3d | 2011-10-10 | 2011-10-13 | 171 | 0d |  |  | WANG - Welder | 24h |
| 173 | 5.1.2.5 | Install cooler sleeves and copper plates |  | 2d | 2011-10-13 | 2011-10-17 | 172 | 0d |  |  | WANG - Mech Tech | 16h |
| 174 | 5.1.2.6 | Weld cooler sleeves to cold mass |  | 2d | 2011-10-17 | 2011-10-19 | 173 | 0d |  |  | WANG - Welder | 16h |
| 175 | 5.1.2.7 | Install Copper straps between 1st stage and Copper plates |  | 1d | 2011-10-20 | 2011-10-21 | 216 | 0d |  |  | WANG - Mech Tech | 8h |
| 176 | 5.1.2.8 | Install the warm leads and HV feedthroughs |  | 1d | 2011-10-21 | 2011-10-24 | 175 | 0d |  |  | WANG - Mech Tech | 8h |
| 177 | 5.1.2.9 | Install the heat intercepts to Copper plates |  | 1d | 2011-10-24 | 2011-10-25 | 176 | 0d |  |  | WANG - Mech Tech | 8h |
| 178 | 5.1.2.10 | Install thermal connection from 1st stage Copper plates to Shield |  | 1d | 2011-10-27 | 2011-10-28 | 211 | 0d |  |  | WANG - Mech Tech | 8h |
| 179 | 5.1.2.11 | Weld plates front and back |  | 3d | 2011-11-07 | 2011-11-10 | 196 | 0d |  |  | WANG - Welder | 24h |

| ID | WBS | Task | Type | Duration | Start | Finish | Predecessors | Total slack | Free slack | Resources | Work |
| --- | --- | --- | --- | --- | --- | --- | --- | --- | --- | --- | --- |
| 180 | 5.1.3 | **Fill and Vent Tower** |  | 16d | 2011-12-21 | 2012-01-12 |  | 0d |  |  | 80h |
| 181 | 5.1.3.1 | Install and weld lower sections of tower to Vacuum vessel |  | 2d | 2011-12-21 | 2011-12-23 | 236 | 0d |  | WANG - Welder | 16h |
| 182 | 5.1.3.2 | Install instrumentation feedthrough |  | 1d | 2011-12-23 | 2012-01-03 | 181 | 0d |  | WANG - Mech Tech | 8h |
| 183 | 5.1.3.3 | Check all instrumentation lines for activity |  | 1d | 2012-01-03 | 2012-01-04 | 182 | 0d |  | LBNL - Elec Tech | 8h |
| 184 | 5.1.3.4 | Instramentation lines installed and tested | milestone | 0d | 2012-01-04 | 2012-01-04 | 183 | 0d |  |  |  |
| 185 | 5.1.3.5 | Weld the upper portion of the tower |  | 2d | 2012-01-04 | 2012-01-06 | 184 | 0d |  | WANG - Welder | 16h |
| 186 | 5.1.3.6 | Complete assembly of fill and vent tower and install |  | 4d | 2012-01-06 | 2012-01-12 | 185 | 0d |  | WANG - Mech Tech | 32h |
| 187 | 5.1.4 | **MLI** |  | 111.5d | 2011-07-14 | 2011-12-16 |  | 76.5d |  |  | 336h |
| 188 | 5.1.4.1 | Wrap cold mass 2 with MLI |  | 8d | 2011-09-28 | 2011-10-10 | 166 | 165.5d | 0d | LBNL - Cryo Tech | 64h |
| 189 | 5.1.4.2 | Sign off quality of MLI layers on cold mass 2 | milestone | 0d | 2011-10-10 | 2011-10-10 | 188 | 181.5d |  |  |  |
| 190 | 5.1.4.3 | Wrap radiation shield 2 with MLI |  | 6d | 2011-07-14 | 2011-07-21 | 54 | 238d | 0d | LBNL - Cryo Tech | 48h |
| 191 | 5.1.4.4 | Sign off quality of MIL layers on radiation shield 2 | milestone | 0d | 2011-07-21 | 2011-07-21 | 190 | 238d |  |  |  |
| 192 | 5.1.4.5 | Wrap cold mass supports with MLI |  | 4d | 2011-10-10 | 2011-10-14 | 188 | 165.5d | 0d | LBNL - Cryo Tech | 32h |
| 193 | 5.1.4.6 | Sign off quality of MLI wrap around supports | milestone | 0d | 2011-10-14 | 2011-10-14 | 192 | 177.5d |  |  |  |
| 194 | 5.1.4.7 | Wrap upper and lower tower area with MLI |  | 4d | 2011-10-28 | 2011-11-03 | 178 | 0d |  | LBNL - Cryo Tech | 32h |
| 195 | 5.1.4.8 | Wrap 1st stage Copper plates to shield connections |  | 2d | 2011-11-03 | 2011-11-07 | 194 | 0d |  | LBNL - Cryo Tech | 16h |
| 196 | 5.1.4.9 | Sign off Tower MLI wrapping | milestone | 0d | 2011-11-07 | 2011-11-07 | 195 | 0d |  |  |  |
| 197 | 5.1.4.10 | Apply MLI to Shield and cold mass bore |  | 6d | 2011-11-10 | 2011-11-18 | 179 | 0d |  | LBNL - Cryo Tech | 48h |
| 198 | 5.1.4.11 | Sign off Shield and cold mass bore wrapping | milestone | 0d | 2011-11-18 | 2011-11-18 | 197 | 0d |  |  |  |
| 199 | 5.1.4.12 | Integrate cold mass MLI with bore MLI |  | 2d | 2011-11-30 | 2011-12-02 | 233 | 142.5d | 0d | LBNL - Cryo Tech | 16h |
| 200 | 5.1.4.13 | Sign off cold mass to bore MLI conection | milestone | 0d | 2011-12-02 | 2011-12-02 | 199 | 142.5d |  |  |  |
| 201 | 5.1.4.14 | Apply MLI to shield ends |  | 4d | 2011-12-01 | 2011-12-07 | 234 | 0d |  | LBNL - Cryo Tech | 32h |
| 202 | 5.1.4.15 | Apply MLI between warm bore and shield bore |  | 4d | 2011-12-07 | 2011-12-13 | 201 | 0d |  | LBNL - Cryo Tech | 32h |
| 203 | 5.1.4.16 | Sign off shield MLI and warm bore MLI | milestone | 0d | 2011-12-13 | 2011-12-13 | 201, 202 | 0d |  |  |  |
| 204 | 5.1.4.17 | Integrate MLI between warm bore and shield ends |  | 2d | 2011-12-14 | 2011-12-16 | 235 | 0d |  | LBNL - Cryo Tech | 16h |
| 205 | 5.1.4.18 | Sign off MLI at warm bore / shield connection | milestone | 0d | 2011-12-16 | 2011-12-16 | 204 | 0d |  |  |  |

| ID | WBS | Task | Type | Duration | Start | Finish | Predecessors | Total slack | Free slack | Resources | Work |
| --- | --- | --- | --- | --- | --- | --- | --- | --- | --- | --- | --- |
| 206 | 5.1.5 | **Instrumentation** |  | 102.5d | 2011-07-13 | 2011-12-02 |  | 75.5d |  |  | 48h |
| 207 | 5.1.5.1 | Install level sensor cold mass 2 - new fill line / vent line |  | 1d | 2011-09-28 | 2011-09-29 | 166 | 188.5d |  | LBNL - Elec Tech | 8h |
| 208 | 5.1.5.2 | Install external temp sensors cold mass 2 |  | 1d | 2011-09-26 | 2011-09-27 | 163 | 190.5d |  | LBNL - Elec Tech | 8h |
| 209 | 5.1.5.3 | Install temp sensors radiation shield 2 |  | 1d | 2011-07-13 | 2011-07-14 | 190SF | 246.5d |  | LBNL - Elec Tech | 8h |
| 210 | 5.1.5.4 | Add temp sensors to cold mass supports |  | 1d | 2011-10-12 | 2011-10-13 | 222 | 178.5d |  | LBNL - Elec Tech | 8h |
| 211 | 5.1.5.5 | Attach thermal sensors to the Copper plates |  | 1d | 2011-10-26 | 2011-10-27 | 214 | 0d |  | LBNL - Elec Tech | 8h |
| 212 | 5.1.5.6 | Apply thermal instramentation top shield |  | 1d | 2011-12-01 | 2011-12-02 | 234 | 142.5d |  | LBNL - Elec Tech | 8h |
| 213 | 5.1.6 | **Current Leads** |  | 1d | 2011-10-25 | 2011-10-26 |  | 0d |  |  | 8h |
| 214 | 5.1.6.1 | Install HTS leads with upper and lower voltage taps |  | 1d | 2011-10-25 | 2011-10-26 | 177 | 0d |  | LBNL - Elec Tech | 8h |
| 215 | 5.1.7 | **Coolers** |  | 69d | 2011-10-19 | 2012-01-24 |  | 0d |  |  | 40h |
| 216 | 5.1.7.1 | Install Single stage cooler to Tower |  | 1d | 2011-10-19 | 2011-10-20 | 174 | 0d |  | WANG - Mech Tech | 8h |
| 217 | 5.1.7.2 | Install the 2 stage coolers to sleeves |  | 2d | 2012-01-18 | 2012-01-20 | 238 | 0d |  | WANG - Mech Tech | 16h |
| 218 | 5.1.7.3 | Install cro cooler hoses |  | 1d | 2012-01-20 | 2012-01-23 | 217 | 0d |  | Dennis Calais | 8h |
| 219 | 5.1.7.4 | Recharge for UK operation |  | 1d | 2012-01-23 | 2012-01-24 | 218 | 105.5d |  | Dennis Calais | 8h |
| 220 | 5.2 | **Assembly** |  | 83d | 2011-10-10 | 2012-02-02 |  | 29d |  |  | 352h |
| 221 | 5.2.1 | Assembly starts on Solenoid 1 | milestone | 0d | 2011-10-10 | 2011-10-10 | 222SS | 184d |  |  |  |
| 222 | 5.2.2 | Suspend shield around the cold mass |  | 2d | 2011-10-10 | 2011-10-12 | 188, 166 | 181d | 0d | WANG - Mech Tech | 16h |
| 223 | 5.2.3 | Install cold mass supports to Vacuum vessel |  | 2d | 2011-10-14 | 2011-10-18 | 192 | 168d | 0d | WANG - Mech Tech | 16h |
| 224 | 5.2.4 | Move vacuum vessel over the shield / cold mass assembly |  | 2d | 2011-10-18 | 2011-10-20 | 223 | 168d | 0d | WANG - Mech Tech | 16h |
| 225 | 5.2.5 | Connect the supports to the cold mass |  | 2d | 2011-10-20 | 2011-10-24 | 224 | 168d | 0d | WANG - Mech Tech | 16h |
| 226 | 5.2.6 | Suspend the shield inside the vacuum vessel |  | 2d | 2011-10-24 | 2011-10-26 | 225 | 168d | 0d | WANG - Mech Tech | 16h |
| 227 | 5.2.7 | Connect cold mass support intercepts to the shield |  | 1d | 2011-10-26 | 2011-10-27 | 226 | 168d | 0d | WANG - Mech Tech | 8h |
| 228 | 5.2.8 | Weld Cooler sleeves to the cold mass stub tubes |  | 2d | 2011-10-27 | 2011-10-31 | 227, 113 | 168d | 0d | WANG - Welder | 16h |
| 229 | 5.2.9 | Add copper sheet to the holes in the shield |  | 1d | 2011-10-31 | 2011-11-01 | 228 | 168d |  | WANG - Mech Tech | 8h |
| 230 | 5.2.10 | Align Vacuum vessel end plate to the cold mass bore |  | 2d | 2011-11-18 | 2011-11-22 | 198 | 0d |  | LBNL - Survey | 16h |
| 231 | 5.2.11 | Align the Cold Mass to the vacuum vessel |  | 1w | 2011-11-22 | 2011-11-29 | 230 | 0d |  | WANG - Mech Tech | 40h |
| 232 | 5.2.12 | Cold mass aligned to the Vacuum Vessel | milestone | 0d | 2011-11-29 | 2011-11-29 | 231 | 0d |  |  |  |
| 233 | 5.2.13 | Install shield bore tube |  | 1d | 2011-11-29 | 2011-11-30 | 232 | 0d |  | WANG - Mech Tech | 8h |
| 234 | 5.2.14 | Weld shield end plates |  | 1d | 2011-11-30 | 2011-12-01 | 233 | 0d |  | WANG - Welder | 8h |
| 235 | 5.2.15 | Install warm bore |  | 1d | 2011-12-13 | 2011-12-14 | 203 | 0d |  | WANG - Mech Tech | 8h |
| 236 | 5.2.16 | Weld end plates to the Vacuum vessel |  | 3d | 2011-12-16 | 2011-12-21 | 205 | 0d |  | WANG - Welder | 24h |
| 237 | 5.2.17 | Vacuum Vessel closed | milestone | 0d | 2011-12-21 | 2011-12-21 | 236 | 132d |  |  |  |
| 238 | 5.2.18 | Detailed leak checking of the Vacuum vessel and cold mass |  | 4d | 2012-01-12 | 2012-01-18 | 186 | 0d |  | LBNL - Mech Tech | 32h |
| 239 | 5.2.19 | Install vacuum system to solenoid |  | 2d | 2012-01-23 | 2012-01-25 | 218 | 0d |  | LBNL - Mech Tech; FermiLab - Physicist | 32h |
| 240 | 5.2.20 | Commision vacuum systems and initial pump down |  | 3d | 2012-01-25 | 2012-01-30 | 239 | 0d |  | FermiLab - Physicist; LBNL - Mech Tech | 48h |
| 241 | 5.2.21 | Test LN2 cooldown system |  | 1d | 2012-01-30 | 2012-01-31 | 240 | 0d |  | FermiLab - Physicist | 8h |
| 242 | 5.2.22 | Connect power leads from feedthroughs to vacuum vessel terminal block |  | 1d | 2012-01-31 | 2012-02-01 | 241 | 0d |  | LBNL - Mech Tech | 8h |
| 243 | 5.2.23 | Connect all instrumentation cables |  | 1d | 2012-02-01 | 2012-02-02 | 242 | 0d |  | LBNL - Elec Tech | 8h |
| 244 | 5.2.24 | Solenoid ready for cool down and training | milestone | 0d | 2012-02-02 | 2012-02-02 | 243 | 0d |  |  |  |

| ID | WBS | Task | Type | Duration | Start | Finish | Predecessors | Total slack | Free slack | Constraint | Resources | Work |
| --- | --- | --- | --- | --- | --- | --- | --- | --- | --- | --- | --- | --- |
| 245 | 6 | **Power and Controls Racks** |  | 227d | 2010-12-08 | 2011-10-28 |  | 169.5d |  |  |  | 24h |
| 246 | 6.1 | Specification of the control requirements |  | 147d | 2010-12-08 | 2011-07-08 |  | 169.5d | 0d | start no earlier than 2010-12-08 |  | 8h |
| 247 | 6.2 | Specification of the controls complete | milestone | 0d | 2011-07-08 | 2011-07-08 | 246 | 169.5d | 0d |  |  |  |
| 248 | 6.3 | Hardware consttruction |  | 3mo | 2011-07-11 | 2011-09-30 | 247 | 177.5d | 0d |  |  |  |
| 249 | 6.4 | Software writting and debugging |  | 3mo | 2011-07-11 | 2011-09-30 | 247 | 177.5d | 0d |  |  |  |
| 250 | 6.5 | Documentation |  | 4mo | 2011-07-11 | 2011-10-28 | 247 | 169.5d |  |  |  | 8h |
| 251 | 6.6 | Shipping |  | 7d | 2011-10-03 | 2011-10-11 | 249, 248 | 177.5d | 0d |  |  | 8h |
| 252 | 6.7 | Unpack and setup |  | 1w | 2011-10-12 | 2011-10-18 | 251 | 177.5d | 0d |  |  |  |
| 253 | 6.8 | Control system ready for operations | milestone | 0d | 2011-10-18 | 2011-10-18 | 252 | 177.5d |  |  |  |  |
| 254 | 7 | **Data Logging** |  | 88.5d | 2011-07-08 | 2011-11-10 |  | 161d |  |  |  | 24h |
| 255 | 7.1 | Specification of system requirements | milestone | 0d | 2011-07-08 | 2011-07-08 | 246 | 169.5d | 0d | start no earlier than 2011-06-01 |  | 8h |
| 256 | 7.2 | Build of hardware |  | 3mo | 2011-07-11 | 2011-09-30 | 255 | 169.5d | 0d |  |  | 8h |
| 257 | 7.3 | Ship Data logging system to WANG |  | 2w | 2011-10-03 | 2011-10-14 | 256 | 169.5d | 0d |  |  |  |
| 258 | 7.4 | Data logging system arrives at WANG | milestone | 0d | 2011-10-14 | 2011-10-14 | 257 | 169.5d | 8.5d |  |  | 8h |
| 259 | 7.5 | Install, test, debug and commission data logging system |  | 2w | 2011-10-27 | 2011-11-10 | 258, 262FF | 161d |  |  |  |  |
| 260 | 8 | **Training and Operations** |  | 128d | 2011-10-27 | 2012-04-24 |  | 7d |  |  |  | 2304h |
| 261 | 8.1 | **Solenoid 2** |  | 64d | 2011-10-27 | 2012-01-25 |  | 64d |  |  |  | 1152h |
| 262 | 8.1.1 | Pumpout |  | 2w | 2011-10-27 | 2011-11-10 | 146 | 70d | 0d |  |  |  |
| 263 | 8.1.2 | LN2 Cooldown |  | 4d | 2011-11-10 | 2011-11-16 | 262 | 70d | 0d |  | Steve Virostek; Roy Preece; Tapio | 96h |
| 264 | 8.1.3 | He Cooldown |  | 2d | 2011-11-16 | 2011-11-18 | 263 | 70d | 0d |  | Steve Virostek; Roy Preece; Tapio | 48h |
| 265 | 8.1.4 | Soak test with coolers operating |  | 2w | 2011-11-18 | 2011-12-02 | 264 | 70d | 0d |  | Steve Virostek; Roy Preece; Tapio | 240h |
| 266 | 8.1.5 | Coil Ramp Up |  | 2d | 2011-12-02 | 2011-12-06 | 265 | 70d | 0d |  | Steve Virostek; Roy Preece; Tapio | 48h |
| 267 | 8.1.6 | Operation with probable Quench / warm up / cool down / operate cycles |  | 6w | 2011-12-06 | 2012-01-25 | 266 | 64d | 0d |  | Steve Virostek; Roy Preece; Tapio | 720h |
| 268 | 8.1.7 | Solenoid 2 ready for Magnetic Measurment Tests | milestone | 0d | 2012-01-25 | 2012-01-25 | 267 | 64d | 0d |  |  |  |

| ID | WBS | Task | Type | Duration | Start | Finish | Predecessors | Total slack | Free slack | Resources | Work |
| --- | --- | --- | --- | --- | --- | --- | --- | --- | --- | --- | --- |
| 269 | 8.2 | **Solenoid 1** |  | 58d | 2012-02-02 | 2012-04-24 |  | 0d |  |  | 1152h |
| 270 | 8.2.1 | Pumpout |  | 2w | 2012-02-02 | 2012-02-16 | 244 | 0d |  |  |  |
| 271 | 8.2.2 | LN2 Cooldown |  | 4d | 2012-02-16 | 2012-02-22 | 270 | 0d |  | Steve Virostek; Roy Preece; Tapio | 96h |
| 272 | 8.2.3 | He Cooldown |  | 2d | 2012-02-22 | 2012-02-24 | 271 | 0d |  | Steve Virostek; Roy Preece; Tapio | 48h |
| 273 | 8.2.4 | Soak test with coolers operating |  | 2w | 2012-02-24 | 2012-03-09 | 272 | 0d |  | Steve Virostek; Roy Preece; Tapio | 240h |
| 274 | 8.2.5 | Coil Ramp Up |  | 2d | 2012-03-09 | 2012-03-13 | 273 | 0d |  | Steve Virostek; Roy Preece; Tapio | 48h |
| 275 | 8.2.6 | Operation with probable Quench / warm up / cool down / operate cycles |  | 6w | 2012-03-13 | 2012-04-24 | 274 | 0d |  | Steve Virostek; Roy Preece; Tapio | 720h |
| 276 | 8.2.7 | Solenoid 1 ready for Magnetic Measurment Tests | milestone | 0d | 2012-04-24 | 2012-04-24 | 275 | 0d |  |  |  |
| 277 | 9 | **Magnetic Measurement** |  | 297.5d | 2011-04-01 | 2012-05-22 |  | 30d |  |  | 592h |
| 278 | 9.1 | **Solenoid 2** |  | 20d | 2012-01-25 | 2012-02-22 |  | 64d |  |  | 296h |
| 279 | 9.1.1 | Delivery of measurement system | milestone | 0d | 2012-01-25 | 2012-01-25 | 268 | 64d | 0d |  | 8h |
| 280 | 9.1.2 | Setup of measurement system |  | 1w | 2012-01-25 | 2012-02-01 | 279, 268 | 64d | 0d | Pierre-Ange; Felix | 80h |
| 281 | 9.1.3 | Magnetic measurements |  | 2w | 2012-02-01 | 2012-02-15 | 280 | 64d | 0d | Felix; Pierre-Ange | 160h |
| 282 | 9.1.4 | Reporting and sign off |  | 3d | 2012-02-15 | 2012-02-20 | 281 | 64d | 0d | Felix; Pierre-Ange | 48h |
| 283 | 9.1.5 | Warm system to room temperature |  | 1w | 2012-02-15 | 2012-02-22 | 281 | 82d | 0d |  |  |
| 284 | 9.1.6 | Solenoid 2 ready for shipping | milestone | 0d | 2012-02-22 | 2012-02-22 | 283 | 82d |  |  |  |
| 285 | 9.2 | **Solenoid 1** |  | 297.5d | 2011-04-01 | 2012-05-22 |  | 30d |  |  | 296h |
| 286 | 9.2.1 | Delivery of measurement system | milestone | 0d | 2011-04-01 | 2011-04-01 |  | 277.5d |  |  | 8h |
| 287 | 9.2.2 | Setup of measurement system |  | 1w | 2012-04-24 | 2012-05-01 | 286, 276 | 0d |  | Felix; Pierre-Ange | 80h |
| 288 | 9.2.3 | Magnetic measurements |  | 2w | 2012-05-01 | 2012-05-15 | 287 | 0d |  | Felix; Pierre-Ange | 160h |
| 289 | 9.2.4 | Reporting and sign off |  | 3d | 2012-05-15 | 2012-05-18 | 288 | 32d |  | Felix; Pierre-Ange | 48h |
| 290 | 9.2.5 | Warm system to room temperature |  | 1w | 2012-05-15 | 2012-05-22 | 288 | 0d |  |  |  |
| 291 | 9.2.6 | Solenoid 1 ready for shipping | milestone | 0d | 2012-05-22 | 2012-05-22 | 290 | 0d |  |  |  |
| 292 | 10 | **Shipping** |  | 96d | 2012-02-20 | 2012-07-03 |  | 0d |  |  | 112h |
| 293 | 10.1 | Install shipping fixtures into Vessels / Towers |  | 1w | 2012-02-22 | 2012-02-29 | 284 | 82d |  | LBNL - Mech Tech | 40h |
| 294 | 10.2 | Package solenoid 2 |  | 1w | 2012-02-20 | 2012-02-27 | 282 | 64d | 0d |  | 8h |
| 295 | 10.3 | Ship Solenoid 2 to UK |  | 4w | 2012-02-27 | 2012-03-26 | 294 | 64d | 0d |  | 8h |
| 296 | 10.4 | Solenoid 2 arrives at RAL | milestone | 0d | 2012-03-26 | 2012-03-26 | 295 | 64d |  |  |  |
| 297 | 10.5 | Install shipping fixtures into Vessels / Towers |  | 1w | 2012-05-22 | 2012-05-29 | 291 | 0d |  | LBNL - Mech Tech | 40h |
| 298 | 10.6 | Package Solenoid 1 |  | 1w | 2012-05-29 | 2012-06-05 | 297 | 0d |  |  | 8h |
| 299 | 10.7 | Ship Solenoid 1 to UK |  | 4w | 2012-06-05 | 2012-07-03 | 298 | 0d |  |  | 8h |
| 300 | 10.8 | Solenoid 1 arrives at RAL | milestone | 0d | 2012-07-03 | 2012-07-03 | 299 | 0d |  |  |  |
